# wgo revamp

Schedule from Planner, 2006-08-18 to 2006-10-04.
Phase: 2.16

## Calendars

- Defecte: Mon-Sun 00:00-23:59.

## Resources

| Resource | Group |
| --- | --- |
| Michael Maclean | planning |
| Simon Rozet | planning |
| Translator X | i18n |
| Máirín Duffy | artwork |
| Lee Tambiah | planning |
| Quim Gil | planning |
| Joachim Noreiko | planning |
| Gergerly Nagy | planning |
| Sigurd Gartmann | planning |

## Schedule

| ID | WBS | Task | Type | Duration | Start | Finish | Predecessors | Complete | Constraint | Resources | Work |
| --- | --- | --- | --- | --- | --- | --- | --- | --- | --- | --- | --- |
| 1 | 1 | 2.16 release | milestone | 0d | 2006-09-06 | 2006-09-06 |  |  | must start on 2006-09-06 |  |  |
| 2 | 2 | 2.16.1 release | milestone | 0d | 2006-10-04 | 2006-10-04 |  |  | must start on 2006-10-04 |  |  |
| 3 | 3 | **Policies** |  |  | 2006-08-18 | 2006-08-22 |  |  |  | Sigurd Gartmann | 119.91h |
| 4 | 3.1 | Policies Draft |  |  | 2006-08-18 | 2006-08-20 |  | 100% |  | Sigurd Gartmann | 71.95h |
| 5 | 3.2 | Policies Revision |  |  | 2006-08-20 | 2006-08-22 | 4 | 100% |  | Sigurd Gartmann | 47.97h |
| 6 | 4 | **Core planning** |  |  | 2006-08-18 | 2006-08-30 |  |  |  | Quim Gil | 311.77h |
| 7 | 4.1 | **Scope** |  |  | 2006-08-18 | 2006-08-24 |  |  |  | Joachim Noreiko | 167.87h |
| 8 | 4.1.1 | Scope Draft |  |  | 2006-08-18 | 2006-08-20 |  | 100% |  | Joachim Noreiko | 71.95h |
| 9 | 4.1.2 | Scope Revision |  |  | 2006-08-20 | 2006-08-22 | 8 | 100% |  | Joachim Noreiko | 47.97h |
| 10 | 4.1.3 | *go Partitioning draft |  |  | 2006-08-20 | 2006-08-22 | 8 | 100% |  | Quim Gil | 47.97h |
| 11 | 4.1.4 | *go Partitioning revision |  |  | 2006-08-22 | 2006-08-24 | 10 |  |  | Quim Gil | 47.97h |
| 12 | 4.2 | **Use cases** |  |  | 2006-08-18 | 2006-08-23 |  |  |  | Quim Gil | 143.89h |
| 13 | 4.2.1 | Use Draft |  |  | 2006-08-18 | 2006-08-21 |  | 100% |  | Quim Gil | 95.93h |
| 14 | 4.2.2 | Use Revision |  |  | 2006-08-21 | 2006-08-23 | 13 | 50% |  | Quim Gil | 47.97h |
| 15 | 4.3 | **Site structure** |  |  | 2006-08-21 | 2006-08-27 | 8, 13 | 75% |  | Joachim Noreiko | 143.9h |
| 16 | 4.3.1 | Site draft |  |  | 2006-08-21 | 2006-08-25 |  | 50% |  | Joachim Noreiko | 95.93h |
| 17 | 4.3.2 | Site Revision |  |  | 2006-08-25 | 2006-08-27 | 16 |  |  | Joachim Noreiko | 47.97h |
| 18 | 4.4 | **Navigation** |  |  | 2006-08-25 | 2006-08-30 | 16 |  |  | Quim Gil | 119.92h |
| 19 | 4.4.1 | Nav. Draft |  |  | 2006-08-25 | 2006-08-28 |  | 50% |  | Quim Gil | 71.95h |
| 20 | 4.4.2 | Nav. Revision |  |  | 2006-08-28 | 2006-08-30 | 19 |  |  | Quim Gil | 47.97h |
| 21 | 5 | **Layout planning** |  |  | 2006-08-18 | 2006-09-02 |  |  |  | Lee Tambiah | 383.72h |
| 22 | 5.1 | **Page components** |  |  | 2006-08-18 | 2006-08-30 |  |  |  | Lee Tambiah | 311.77h |
| 23 | 5.1.1 | Page components draft |  |  | 2006-08-18 | 2006-08-22 |  | 100% |  | Lee Tambiah | 119.92h |
| 24 | 5.1.2 | Page components revision |  |  | 2006-08-23 | 2006-08-26 | 14 |  |  | Lee Tambiah | 71.95h |
| 25 | 5.1.3 | Home components draft |  |  | 2006-08-20 | 2006-08-22 | 23SS+48h | 100% |  | Lee Tambiah | 71.95h |
| 26 | 5.1.4 | Home components revision |  |  | 2006-08-27 | 2006-08-30 | 17, 25 |  |  | Lee Tambiah | 71.95h |

| ID | WBS | Task | Start | Finish | Predecessors | Complete | Resources | Work |
| --- | --- | --- | --- | --- | --- | --- | --- | --- |
| 27 | 5.2 | **Page structure** | 2006-08-22 | 2006-09-02 |  |  | Lee Tambiah | 263.82h |
| 28 | 5.2.1 | Pagestr. draft | 2006-08-22 | 2006-08-25 | 25 |  | Lee Tambiah | 71.95h |
| 29 | 5.2.2 | Pagestr. revision | 2006-08-26 | 2006-08-29 | 24 |  | Lee Tambiah | 71.95h |
| 30 | 5.2.3 | Homestr. draft | 2006-08-27 | 2006-08-30 | 28FS+48h, 25 |  | Lee Tambiah | 71.95h |
| 31 | 5.2.4 | Homestr. revision | 2006-08-30 | 2006-09-02 | 30, 26 |  | Lee Tambiah | 71.95h |
| 32 | 6 | **Look&Feel** | 2006-09-06 | 2006-09-22 | 1SS |  | Máirín Duffy | 407.71h |
| 33 | 6.1 | L&F draft | 2006-09-06 | 2006-09-15 |  |  | Máirín Duffy | 239.83h |
| 34 | 6.2 | L&F tuning | 2006-09-15 | 2006-09-22 | 33 |  | Máirín Duffy | 167.88h |
| 35 | 7 | **CMS selection** | 2006-09-06 | 2006-09-30 |  |  | Gergerly Nagy | 599.57h |
| 36 | 7.1 | 1st round draft | 2006-09-06 | 2006-09-14 | 42SS | 10% | Gergerly Nagy | 215.85h |
| 37 | 7.2 | 1st round revision | 2006-09-14 | 2006-09-16 | 36 |  | Gergerly Nagy | 47.97h |
| 38 | 7.3 | final round draft | 2006-09-16 | 2006-09-26 | 33, 43, 37 |  | Gergerly Nagy | 239.83h |
| 39 | 7.4 | final round revision | 2006-09-26 | 2006-09-30 | 38 |  | Gergerly Nagy | 95.93h |
| 40 | 7.5 | Develop test themes | 2006-09-19 | 2006-09-24 | 31, 29, 38SS+72h, 33 |  | Lee Tambiah | 119.92h |
| 41 | 8 | **i18n requirements** | 2006-09-06 | 2006-09-15 | 1SS |  | Translator X | 239.82h |
| 42 | 8.1 | Minimal and optimal reqs draft | 2006-09-06 | 2006-09-12 |  | 25% | Translator X | 167.88h |
| 43 | 8.2 | Minimal and optimal reqs revision | 2006-09-12 | 2006-09-15 | 42 |  | Translator X | 71.95h |
| 44 | 9 | **GNOME Products alpha** | 2006-08-18 | 2006-09-02 |  |  | Simon Rozet | 383.72h |
| 45 | 9.1 | Relation with gnomefiles.org | 2006-08-18 | 2006-08-18 |  | 100% | Quim Gil | 23.98h |
| 46 | 9.2 | Reqs & workflow draft | 2006-08-18 | 2006-08-22 |  |  | Simon Rozet | 119.92h |
| 47 | 9.3 | Reqs & workflow revision | 2006-08-22 | 2006-08-24 | 46 |  | Simon Rozet | 47.97h |
| 48 | 9.4 | List of sections and products draft | 2006-08-22 | 2006-08-25 | 46 |  | Simon Rozet | 71.95h |
| 49 | 9.5 | List of sections and products revision | 2006-08-25 | 2006-08-28 | 48 |  | Simon Rozet | 71.95h |
| 50 | 9.6 | Page components draft | 2006-08-22 | 2006-08-25 | 46 |  | Simon Rozet | 71.95h |
| 51 | 9.7 | Page components revision | 2006-08-26 | 2006-08-28 | 50, 24 |  | Simon Rozet | 47.97h |
| 52 | 9.8 | Page structure draft | 2006-08-25 | 2006-08-28 | 50 |  | Simon Rozet | 71.95h |
| 53 | 9.9 | Pages structure revision | 2006-08-29 | 2006-08-31 | 52, 29 |  | Simon Rozet | 47.97h |
| 54 | 9.10 | GNOME Products alpha | 2006-08-26 | 2006-09-02 | 51SS, 49SS |  | Simon Rozet | 167.88h |

| ID | WBS | Task | Start | Finish | Predecessors | Resources | Work |
| --- | --- | --- | --- | --- | --- | --- | --- |
| 55 | 10 | **GNOME Products beta** | 2006-09-06 | 2006-09-30 | 54, 1SS | Simon Rozet | 599.57h |
| 56 | 10.1 | Alpha testing | 2006-09-06 | 2006-09-20 |  | Simon Rozet | 359.75h |
| 57 | 10.2 | Beta Look&Feel | 2006-09-22 | 2006-09-25 | 34 | Simon Rozet | 71.95h |
| 58 | 10.3 | Beta product pages | 2006-09-06 | 2006-09-15 |  | Simon Rozet | 239.83h |
| 59 | 10.4 | Beta DOAP implementation | 2006-09-11 | 2006-09-20 | 58SS+120h | Simon Rozet | 239.83h |
| 60 | 10.5 | CMS integration??? | 2006-09-26 | 2006-09-30 | 38 | Simon Rozet | 95.93h |
| 61 | 10.6 | Beta release??? | 2006-09-25 | 2006-09-30 | 59, 58, 57, 56 | Simon Rozet | 119.92h |
| 62 | 11 | **News gateway alpha** | 2006-08-18 | 2006-09-02 |  | Michael Maclean | 383.72h |
| 63 | 11.1 | News reqs and workflow draft | 2006-08-18 | 2006-08-20 |  | Michael Maclean | 71.72h |
| 64 | 11.2 | News reqs and workflow revision | 2006-08-20 | 2006-08-22 | 63 | Michael Maclean | 47.97h |
| 65 | 11.3 | News sources list draft | 2006-08-20 | 2006-08-23 | 63 | Michael Maclean | 71.95h |
| 66 | 11.4 | News sources list revision | 2006-08-23 | 2006-08-25 | 65 | Michael Maclean | 47.97h |
| 67 | 11.5 | News components draft | 2006-08-20 | 2006-08-23 | 63 | Michael Maclean | 71.95h |
| 68 | 11.6 | News components revision | 2006-08-26 | 2006-08-28 | 24, 67 | Michael Maclean | 47.97h |
| 69 | 11.7 | News structure draft | 2006-08-28 | 2006-08-31 | 68 | Michael Maclean | 71.95h |
| 70 | 11.8 | News structure revision | 2006-08-31 | 2006-09-02 | 29, 69 | Michael Maclean | 47.97h |
| 71 | 11.9 | News gateway alpha | 2006-08-26 | 2006-09-02 | 68SS | Michael Maclean | 167.88h |
| 72 | 12 | **News gateway beta** | 2006-09-06 | 2006-09-29 | 62, 1SS | Michael Maclean | 575.59h |
| 73 | 12.1 | Alpha news testing | 2006-09-06 | 2006-09-12 |  | Michael Maclean | 167.88h |
| 74 | 12.2 | Beta news look&feel | 2006-09-22 | 2006-09-25 | 34 | Michael Maclean | 71.95h |
| 75 | 12.3 | Beta release | 2006-09-25 | 2006-09-29 | 74 |  | 95.93h |
